# Contrat avec vidéo V1

Schedule from MS Project, 2014-01-01 to 2015-04-17, costs in €.
3MI

## Calendars

- Standard: Mon-Fri 08:00-12:00, 13:00-17:00; Sat-Sun off.

## Resources

| Resource | Group | Rate |
| --- | --- | --- |
| Chef de projet | Médiaformation | 67.85 |
| Scénariste | Sous-traitant | 100 |
| Auteur | Sous-traitant | 100 |
| Développeur informaticien | Mediaformation | 65.85 |
| Photographe | Sous-traitant | 60 |
| Infographiste | Mediaformation | 49.71 |
| Responsable de production | Mediaformation | 54.12 |
| Réalisateur Audio-vidéo | Sous-traitant |  |
| Frais de déplacement | Mediaformation |  |

## Schedule

| ID | WBS | Task | Type | Duration | Start | Finish | Predecessors | Total slack | Free slack | Constraint | Resources | Work | Cost |
| --- | --- | --- | --- | --- | --- | --- | --- | --- | --- | --- | --- | --- | --- |
| 1 | 1 | **PREVISIONS EXPLOITATION MEDIA FORMATION EXERCICE N°1** |  | 338d | 2014-01-01 | 2015-04-17 |  | 0d |  |  |  | 8080h | 588,583.2 |
| 2 | 1.1 | Fin de création de l'entreprise et début d'exploitation | milestone | 0d | 2014-01-01 | 2014-01-01 |  | 338d | 0d | start no earlier than 2014-01-01 |  |  |  |
| 3 | 1.2 | Lancement de l'exploitation et prospection commerciale pour signature 1er Contrat | milestone | 0d | 2014-01-01 | 2014-01-01 | 2 | 338d |  |  |  |  |  |
| 4 | 1.3 | Signatures des contrats sans vidéo A1 |  | 194d | 2014-03-31 | 2014-12-25 |  | 81d |  | start no earlier than 2014-03-31 |  |  |  |
| 5 | 1.4 | **CONTRAT sans Vidéo N°1** |  | 80d | 2014-03-31 | 2014-07-18 |  | 195d |  |  |  | 808h | 58,858.32 |
| 6 | 1.4.1 | Repérer, extraire (besoins, pbs, désirs,…) à partir des entretiens qualitatifs |  | 10d | 2014-03-31 | 2014-04-11 |  | 195d | 0d | start no earlier than 2014-03-31 | Chef de projet [50%]; Frais de déplacement | 40h | 3,714 |
| 7 | 1.4.2 | Modéliser les contenus |  | 15d | 2014-04-14 | 2014-05-02 | 6 | 195d | 0d |  | Auteur [66.7%]; Responsable de production [13.3%] | 96h | 8,865.92 |
| 8 | 1.4.3 | Scénariser le programme de formation |  | 10d | 2014-05-05 | 2014-05-16 | 7 | 195d | 0d |  | Scénariste [70%]; Chef de projet [10%] | 64h | 6,142.8 |
| 9 | 1.4.4 | **Produire le programme** |  | 20d | 2014-05-19 | 2014-06-13 |  | 195d |  |  |  | 384h | 25,501.12 |
| 10 | 1.4.4.1 | Rédiger les textes |  | 10d | 2014-05-19 | 2014-05-30 | 8 | 195d | 0d |  | Auteur [80%] | 64h | 6,400 |
| 11 | 1.4.4.2 | Réaliser les photographies |  | 5d | 2014-05-19 | 2014-05-23 | 8 | 200d | 5d |  | Photographe [80%] | 32h | 1,920 |
| 12 | 1.4.4.3 | Dessiner les illustrations |  | 10d | 2014-05-19 | 2014-05-30 | 8 | 195d | 0d |  | Infographiste [80%]; Responsable de production [20%] | 80h | 4,047.36 |
| 13 | 1.4.4.4 | Réaliser le montage informatique |  | 10d | 2014-06-02 | 2014-06-13 | 10, 11, 12 | 195d | 0d |  | Développeur informaticien [80%]; Responsable de production [40%] | 96h | 5,946.24 |
| 14 | 1.4.4.5 | Développer le dispositif d'utilisation du programme |  | 20d | 2014-05-19 | 2014-06-13 | 8 | 220d |  |  | Développeur informaticien [60%]; Responsable de production [10%] | 112h | 7,187.52 |
| 15 | 1.4.5 | **Evaluer le programme** |  | 25d | 2014-06-16 | 2014-07-18 |  | 195d |  |  |  | 184h | 11,920.48 |
| 16 | 1.4.5.1 | Réaliser le test alpha |  | 5d | 2014-06-16 | 2014-06-20 | 13 | 195d | 0d |  | Responsable de production [40%]; Développeur informaticien [40%]; Infographiste [40%] | 48h | 2,714.88 |
| 17 | 1.4.5.2 | Apporter les corrections suite au test alpha |  | 5d | 2014-06-23 | 2014-06-27 | 16 | 195d | 0d |  | Développeur informaticien [40%]; Infographiste [40%] | 32h | 1,848.96 |
| 18 | 1.4.5.3 | Réaliser le test Bèta |  | 10d | 2014-06-30 | 2014-07-11 | 17 | 195d | 0d |  | Chef de projet [30%]; Responsable de production [30%]; Développeur informaticien [30%]; Frais de déplacement | 72h | 5,507.68 |
| 19 | 1.4.5.4 | Apporter les corrections suite au test Béta |  | 5d | 2014-07-14 | 2014-07-18 | 18 | 195d |  |  | Développeur informaticien [40%]; Infographiste [40%] | 32h | 1,848.96 |
| 20 | 1.4.6 | Manager le projet (5% du travail total de la main d'œuvre) |  | 80d | 2014-03-31 | 2014-07-18 |  | 195d |  | start no earlier than 2014-03-31 | Chef de projet [6.2%] | 40h | 2,714 |
| 21 | 1.5 | **CONTRAT sans Vidéo N°2** |  | 80d | 2014-04-30 | 2014-08-19 |  | 173d |  |  |  | 808h | 58,858.32 |
| 22 | 1.5.1 | Repérer, extraire (besoins, pbs, désirs,…) à partir des entretiens qualitatifs |  | 10d | 2014-04-30 | 2014-05-13 |  | 173d | 0d | start no earlier than 2014-04-30 | Chef de projet [50%]; Frais de déplacement | 40h | 3,714 |
| 23 | 1.5.2 | Modéliser les contenus |  | 15d | 2014-05-14 | 2014-06-03 | 22 | 173d | 0d |  | Auteur [66.7%]; Responsable de production [13.3%] | 96h | 8,865.92 |
| 24 | 1.5.3 | Scénariser le programme de formation |  | 10d | 2014-06-04 | 2014-06-17 | 23 | 173d | 0d |  | Scénariste [70%]; Chef de projet [10%] | 64h | 6,142.8 |

| ID | WBS | Task | Duration | Start | Finish | Predecessors | Total slack | Free slack | Constraint | Resources | Work | Cost |
| --- | --- | --- | --- | --- | --- | --- | --- | --- | --- | --- | --- | --- |
| 25 | 1.5.4 | **Produire le programme** | 20d | 2014-06-18 | 2014-07-15 |  | 173d |  |  |  | 384h | 25,501.12 |
| 26 | 1.5.4.1 | Rédiger les textes | 10d | 2014-06-18 | 2014-07-01 | 24 | 173d | 0d |  | Auteur [80%] | 64h | 6,400 |
| 27 | 1.5.4.2 | Réaliser les photographies | 5d | 2014-06-18 | 2014-06-24 | 24 | 178d | 5d |  | Photographe [80%] | 32h | 1,920 |
| 28 | 1.5.4.3 | Dessiner les illustrations | 10d | 2014-06-18 | 2014-07-01 | 24 | 173d | 0d |  | Infographiste [80%]; Responsable de production [20%] | 80h | 4,047.36 |
| 29 | 1.5.4.4 | Réaliser le montage informatique | 10d | 2014-07-02 | 2014-07-15 | 26, 27, 28 | 173d | 0d |  | Développeur informaticien [80%]; Responsable de production [40%] | 96h | 5,946.24 |
| 30 | 1.5.4.5 | Développer le dispositif d'utilisation du programme | 20d | 2014-06-18 | 2014-07-15 | 24 | 198d |  |  | Développeur informaticien [60%]; Responsable de production [10%] | 112h | 7,187.52 |
| 31 | 1.5.5 | **Evaluer le programme** | 25d | 2014-07-16 | 2014-08-19 |  | 173d |  |  |  | 184h | 11,920.48 |
| 32 | 1.5.5.1 | Réaliser le test alpha | 5d | 2014-07-16 | 2014-07-22 | 29 | 173d | 0d |  | Responsable de production [40%]; Développeur informaticien [40%]; Infographiste [40%] | 48h | 2,714.88 |
| 33 | 1.5.5.2 | Apporter les corrections suite au test alpha | 5d | 2014-07-23 | 2014-07-29 | 32 | 173d | 0d |  | Développeur informaticien [40%]; Infographiste [40%] | 32h | 1,848.96 |
| 34 | 1.5.5.3 | Réaliser le test Bèta | 10d | 2014-07-30 | 2014-08-12 | 33 | 173d | 0d |  | Chef de projet [30%]; Responsable de production [30%]; Développeur informaticien [30%]; Frais de déplacement | 72h | 5,507.68 |
| 35 | 1.5.5.4 | Apporter les corrections suite au test Béta | 5d | 2014-08-13 | 2014-08-19 | 34 | 173d |  |  | Développeur informaticien [40%]; Infographiste [40%] | 32h | 1,848.96 |
| 36 | 1.5.6 | Manager le projet (5% du travail total de la main d'œuvre) | 80d | 2014-04-30 | 2014-08-19 |  | 173d |  | start no earlier than 2014-04-30 | Chef de projet [6.2%] | 40h | 2,714 |
| 37 | 1.6 | **CONTRAT sans Vidéo N°3** | 80d | 2014-05-28 | 2014-09-16 |  | 153d |  |  |  | 808h | 58,858.32 |
| 38 | 1.6.1 | Repérer, extraire (besoins, pbs, désirs,…) à partir des entretiens qualitatifs | 10d | 2014-05-28 | 2014-06-10 |  | 153d | 0d | start no earlier than 2014-05-28 | Chef de projet [50%]; Frais de déplacement | 40h | 3,714 |
| 39 | 1.6.2 | Modéliser les contenus | 15d | 2014-06-11 | 2014-07-01 | 38 | 153d | 0d |  | Auteur [66.7%]; Responsable de production [13.3%] | 96h | 8,865.92 |
| 40 | 1.6.3 | Scénariser le programme de formation | 10d | 2014-07-02 | 2014-07-15 | 39 | 153d | 0d |  | Scénariste [70%]; Chef de projet [10%] | 64h | 6,142.8 |
| 41 | 1.6.4 | **Produire le programme** | 20d | 2014-07-16 | 2014-08-12 |  | 153d |  |  |  | 384h | 25,501.12 |
| 42 | 1.6.4.1 | Rédiger les textes | 10d | 2014-07-16 | 2014-07-29 | 40 | 153d | 0d |  | Auteur [80%] | 64h | 6,400 |
| 43 | 1.6.4.2 | Réaliser les photographies | 5d | 2014-07-16 | 2014-07-22 | 40 | 158d | 5d |  | Photographe [80%] | 32h | 1,920 |
| 44 | 1.6.4.3 | Dessiner les illustrations | 10d | 2014-07-16 | 2014-07-29 | 40 | 153d | 0d |  | Infographiste [80%]; Responsable de production [20%] | 80h | 4,047.36 |
| 45 | 1.6.4.4 | Réaliser le montage informatique | 10d | 2014-07-30 | 2014-08-12 | 42, 43, 44 | 153d | 0d |  | Développeur informaticien [80%]; Responsable de production [40%] | 96h | 5,946.24 |
| 46 | 1.6.4.5 | Développer le dispositif d'utilisation du programme | 20d | 2014-07-16 | 2014-08-12 | 40 | 178d |  |  | Développeur informaticien [60%]; Responsable de production [10%] | 112h | 7,187.52 |
| 47 | 1.6.5 | **Evaluer le programme** | 25d | 2014-08-13 | 2014-09-16 |  | 153d |  |  |  | 184h | 11,920.48 |
| 48 | 1.6.5.1 | Réaliser le test alpha | 5d | 2014-08-13 | 2014-08-19 | 45 | 153d | 0d |  | Responsable de production [40%]; Développeur informaticien [40%]; Infographiste [40%] | 48h | 2,714.88 |
| 49 | 1.6.5.2 | Apporter les corrections suite au test alpha | 5d | 2014-08-20 | 2014-08-26 | 48 | 153d | 0d |  | Développeur informaticien [40%]; Infographiste [40%] | 32h | 1,848.96 |
| 50 | 1.6.5.3 | Réaliser le test Bèta | 10d | 2014-08-27 | 2014-09-09 | 49 | 153d | 0d |  | Chef de projet [30%]; Responsable de production [30%]; Développeur informaticien [30%]; Frais de déplacement | 72h | 5,507.68 |
| 51 | 1.6.5.4 | Apporter les corrections suite au test Béta | 5d | 2014-09-10 | 2014-09-16 | 50 | 153d |  |  | Développeur informaticien [40%]; Infographiste [40%] | 32h | 1,848.96 |
| 52 | 1.6.6 | Manager le projet (5% du travail total de la main d'œuvre) | 80d | 2014-05-28 | 2014-09-16 |  | 153d |  | start no earlier than 2014-05-28 | Chef de projet [6.2%] | 40h | 2,714 |

| ID | WBS | Task | Duration | Start | Finish | Predecessors | Total slack | Free slack | Constraint | Resources | Work | Cost |
| --- | --- | --- | --- | --- | --- | --- | --- | --- | --- | --- | --- | --- |
| 53 | 1.7 | **CONTRAT sans Vidéo N°4** | 80d | 2014-06-30 | 2014-10-17 |  | 130d |  |  |  | 808h | 58,858.32 |
| 54 | 1.7.1 | Repérer, extraire (besoins, pbs, désirs,…) à partir des entretiens qualitatifs | 10d | 2014-06-30 | 2014-07-11 |  | 130d | 0d | start no earlier than 2014-06-30 | Chef de projet [50%]; Frais de déplacement | 40h | 3,714 |
| 55 | 1.7.2 | Modéliser les contenus | 15d | 2014-07-14 | 2014-08-01 | 54 | 130d | 0d |  | Auteur [66.7%]; Responsable de production [13.3%] | 96h | 8,865.92 |
| 56 | 1.7.3 | Scénariser le programme de formation | 10d | 2014-08-04 | 2014-08-15 | 55 | 130d | 0d |  | Scénariste [70%]; Chef de projet [10%] | 64h | 6,142.8 |
| 57 | 1.7.4 | **Produire le programme** | 20d | 2014-08-18 | 2014-09-12 |  | 130d |  |  |  | 384h | 25,501.12 |
| 58 | 1.7.4.1 | Rédiger les textes | 10d | 2014-08-18 | 2014-08-29 | 56 | 130d | 0d |  | Auteur [80%] | 64h | 6,400 |
| 59 | 1.7.4.2 | Réaliser les photographies | 5d | 2014-08-18 | 2014-08-22 | 56 | 135d | 5d |  | Photographe [80%] | 32h | 1,920 |
| 60 | 1.7.4.3 | Dessiner les illustrations | 10d | 2014-08-18 | 2014-08-29 | 56 | 130d | 0d |  | Infographiste [80%]; Responsable de production [20%] | 80h | 4,047.36 |
| 61 | 1.7.4.4 | Réaliser le montage informatique | 10d | 2014-09-01 | 2014-09-12 | 58, 59, 60 | 130d | 0d |  | Développeur informaticien [80%]; Responsable de production [40%] | 96h | 5,946.24 |
| 62 | 1.7.4.5 | Développer le dispositif d'utilisation du programme | 20d | 2014-08-18 | 2014-09-12 | 56 | 155d |  |  | Développeur informaticien [60%]; Responsable de production [10%] | 112h | 7,187.52 |
| 63 | 1.7.5 | **Evaluer le programme** | 25d | 2014-09-15 | 2014-10-17 |  | 130d |  |  |  | 184h | 11,920.48 |
| 64 | 1.7.5.1 | Réaliser le test alpha | 5d | 2014-09-15 | 2014-09-19 | 61 | 130d | 0d |  | Responsable de production [40%]; Développeur informaticien [40%]; Infographiste [40%] | 48h | 2,714.88 |
| 65 | 1.7.5.2 | Apporter les corrections suite au test alpha | 5d | 2014-09-22 | 2014-09-26 | 64 | 130d | 0d |  | Développeur informaticien [40%]; Infographiste [40%] | 32h | 1,848.96 |
| 66 | 1.7.5.3 | Réaliser le test Bèta | 10d | 2014-09-29 | 2014-10-10 | 65 | 130d | 0d |  | Chef de projet [30%]; Responsable de production [30%]; Développeur informaticien [30%]; Frais de déplacement | 72h | 5,507.68 |
| 67 | 1.7.5.4 | Apporter les corrections suite au test Béta | 5d | 2014-10-13 | 2014-10-17 | 66 | 130d |  |  | Développeur informaticien [40%]; Infographiste [40%] | 32h | 1,848.96 |
| 68 | 1.7.6 | Manager le projet (5% du travail total de la main d'œuvre) | 80d | 2014-06-30 | 2014-10-17 |  | 130d |  | start no earlier than 2014-06-30 | Chef de projet [6.2%] | 40h | 2,714 |
| 69 | 1.8 | **CONTRAT sans Vidéo N°5** | 80d | 2014-07-28 | 2014-11-14 |  | 110d |  |  |  | 808h | 58,858.32 |
| 70 | 1.8.1 | Repérer, extraire (besoins, pbs, désirs,…) à partir des entretiens qualitatifs | 10d | 2014-07-28 | 2014-08-08 |  | 110d | 0d | start no earlier than 2014-07-28 | Chef de projet [50%]; Frais de déplacement | 40h | 3,714 |
| 71 | 1.8.2 | Modéliser les contenus | 15d | 2014-08-11 | 2014-08-29 | 70 | 110d | 0d |  | Auteur [66.7%]; Responsable de production [13.3%] | 96h | 8,865.92 |
| 72 | 1.8.3 | Scénariser le programme de formation | 10d | 2014-09-01 | 2014-09-12 | 71 | 110d | 0d |  | Scénariste [70%]; Chef de projet [10%] | 64h | 6,142.8 |
| 73 | 1.8.4 | **Produire le programme** | 20d | 2014-09-15 | 2014-10-10 |  | 110d |  |  |  | 384h | 25,501.12 |
| 74 | 1.8.4.1 | Rédiger les textes | 10d | 2014-09-15 | 2014-09-26 | 72 | 110d | 0d |  | Auteur [80%] | 64h | 6,400 |
| 75 | 1.8.4.2 | Réaliser les photographies | 5d | 2014-09-15 | 2014-09-19 | 72 | 115d | 5d |  | Photographe [80%] | 32h | 1,920 |
| 76 | 1.8.4.3 | Dessiner les illustrations | 10d | 2014-09-15 | 2014-09-26 | 72 | 110d | 0d |  | Infographiste [80%]; Responsable de production [20%] | 80h | 4,047.36 |
| 77 | 1.8.4.4 | Réaliser le montage informatique | 10d | 2014-09-29 | 2014-10-10 | 74, 75, 76 | 110d | 0d |  | Développeur informaticien [80%]; Responsable de production [40%] | 96h | 5,946.24 |
| 78 | 1.8.4.5 | Développer le dispositif d'utilisation du programme | 20d | 2014-09-15 | 2014-10-10 | 72 | 135d |  |  | Développeur informaticien [60%]; Responsable de production [10%] | 112h | 7,187.52 |

| ID | WBS | Task | Duration | Start | Finish | Predecessors | Total slack | Free slack | Constraint | Resources | Work | Cost |
| --- | --- | --- | --- | --- | --- | --- | --- | --- | --- | --- | --- | --- |
| 79 | 1.8.5 | **Evaluer le programme** | 25d | 2014-10-13 | 2014-11-14 |  | 110d |  |  |  | 184h | 11,920.48 |
| 80 | 1.8.5.1 | Réaliser le test alpha | 5d | 2014-10-13 | 2014-10-17 | 77 | 110d | 0d |  | Responsable de production [40%]; Développeur informaticien [40%]; Infographiste [40%] | 48h | 2,714.88 |
| 81 | 1.8.5.2 | Apporter les corrections suite au test alpha | 5d | 2014-10-20 | 2014-10-24 | 80 | 110d | 0d |  | Développeur informaticien [40%]; Infographiste [40%] | 32h | 1,848.96 |
| 82 | 1.8.5.3 | Réaliser le test Bèta | 10d | 2014-10-27 | 2014-11-07 | 81 | 110d | 0d |  | Chef de projet [30%]; Responsable de production [30%]; Développeur informaticien [30%]; Frais de déplacement | 72h | 5,507.68 |
| 83 | 1.8.5.4 | Apporter les corrections suite au test Béta | 5d | 2014-11-10 | 2014-11-14 | 82 | 110d |  |  | Développeur informaticien [40%]; Infographiste [40%] | 32h | 1,848.96 |
| 84 | 1.8.6 | Manager le projet (5% du travail total de la main d'œuvre) | 80d | 2014-07-28 | 2014-11-14 |  | 110d |  | start no earlier than 2014-07-28 | Chef de projet [6.2%] | 40h | 2,714 |
| 85 | 1.9 | **CONTRAT sans Vidéo N°6** | 80d | 2014-09-01 | 2014-12-19 |  | 85d |  |  |  | 808h | 58,858.32 |
| 86 | 1.9.1 | Repérer, extraire (besoins, pbs, désirs,…) à partir des entretiens qualitatifs | 10d | 2014-09-01 | 2014-09-12 |  | 85d | 0d | start no earlier than 2014-09-01 | Chef de projet [50%]; Frais de déplacement | 40h | 3,714 |
| 87 | 1.9.2 | Modéliser les contenus | 15d | 2014-09-15 | 2014-10-03 | 86 | 85d | 0d |  | Auteur [66.7%]; Responsable de production [13.3%] | 96h | 8,865.92 |
| 88 | 1.9.3 | Scénariser le programme de formation | 10d | 2014-10-06 | 2014-10-17 | 87 | 85d | 0d |  | Scénariste [70%]; Chef de projet [10%] | 64h | 6,142.8 |
| 89 | 1.9.4 | **Produire le programme** | 20d | 2014-10-20 | 2014-11-14 |  | 85d |  |  |  | 384h | 25,501.12 |
| 90 | 1.9.4.1 | Rédiger les textes | 10d | 2014-10-20 | 2014-10-31 | 88 | 85d | 0d |  | Auteur [80%] | 64h | 6,400 |
| 91 | 1.9.4.2 | Réaliser les photographies | 5d | 2014-10-20 | 2014-10-24 | 88 | 90d | 5d |  | Photographe [80%] | 32h | 1,920 |
| 92 | 1.9.4.3 | Dessiner les illustrations | 10d | 2014-10-20 | 2014-10-31 | 88 | 85d | 0d |  | Infographiste [80%]; Responsable de production [20%] | 80h | 4,047.36 |
| 93 | 1.9.4.4 | Réaliser le montage informatique | 10d | 2014-11-03 | 2014-11-14 | 90, 91, 92 | 85d | 0d |  | Développeur informaticien [80%]; Responsable de production [40%] | 96h | 5,946.24 |
| 94 | 1.9.4.5 | Développer le dispositif d'utilisation du programme | 20d | 2014-10-20 | 2014-11-14 | 88 | 110d |  |  | Développeur informaticien [60%]; Responsable de production [10%] | 112h | 7,187.52 |
| 95 | 1.9.5 | **Evaluer le programme** | 25d | 2014-11-17 | 2014-12-19 |  | 85d |  |  |  | 184h | 11,920.48 |
| 96 | 1.9.5.1 | Réaliser le test alpha | 5d | 2014-11-17 | 2014-11-21 | 93 | 85d | 0d |  | Responsable de production [40%]; Développeur informaticien [40%]; Infographiste [40%] | 48h | 2,714.88 |
| 97 | 1.9.5.2 | Apporter les corrections suite au test alpha | 5d | 2014-11-24 | 2014-11-28 | 96 | 85d | 0d |  | Développeur informaticien [40%]; Infographiste [40%] | 32h | 1,848.96 |
| 98 | 1.9.5.3 | Réaliser le test Bèta | 10d | 2014-12-01 | 2014-12-12 | 97 | 85d | 0d |  | Chef de projet [30%]; Responsable de production [30%]; Développeur informaticien [30%]; Frais de déplacement | 72h | 5,507.68 |
| 99 | 1.9.5.4 | Apporter les corrections suite au test Béta | 5d | 2014-12-15 | 2014-12-19 | 98 | 85d |  |  | Développeur informaticien [40%]; Infographiste [40%] | 32h | 1,848.96 |
| 100 | 1.9.6 | Manager le projet (5% du travail total de la main d'œuvre) | 80d | 2014-09-01 | 2014-12-19 |  | 85d |  | start no earlier than 2014-09-01 | Chef de projet [6.2%] | 40h | 2,714 |
| 101 | 1.10 | **CONTRAT sans Vidéo N°7** | 80d | 2014-09-30 | 2015-01-19 |  | 64d |  |  |  | 808h | 58,858.32 |
| 102 | 1.10.1 | Repérer, extraire (besoins, pbs, désirs,…) à partir des entretiens qualitatifs | 10d | 2014-09-30 | 2014-10-13 |  | 64d | 0d | start no earlier than 2014-09-30 | Chef de projet [50%]; Frais de déplacement | 40h | 3,714 |
| 103 | 1.10.2 | Modéliser les contenus | 15d | 2014-10-14 | 2014-11-03 | 102 | 64d | 0d |  | Auteur [66.7%]; Responsable de production [13.3%] | 96h | 8,865.92 |
| 104 | 1.10.3 | Scénariser le programme de formation | 10d | 2014-11-04 | 2014-11-17 | 103 | 64d | 0d |  | Scénariste [70%]; Chef de projet [10%] | 64h | 6,142.8 |

| ID | WBS | Task | Duration | Start | Finish | Predecessors | Total slack | Free slack | Constraint | Resources | Work | Cost |
| --- | --- | --- | --- | --- | --- | --- | --- | --- | --- | --- | --- | --- |
| 105 | 1.10.4 | **Produire le programme** | 20d | 2014-11-18 | 2014-12-15 |  | 64d |  |  |  | 384h | 25,501.12 |
| 106 | 1.10.4.1 | Rédiger les textes | 10d | 2014-11-18 | 2014-12-01 | 104 | 64d | 0d |  | Auteur [80%] | 64h | 6,400 |
| 107 | 1.10.4.2 | Réaliser les photographies | 5d | 2014-11-18 | 2014-11-24 | 104 | 69d | 5d |  | Photographe [80%] | 32h | 1,920 |
| 108 | 1.10.4.3 | Dessiner les illustrations | 10d | 2014-11-18 | 2014-12-01 | 104 | 64d | 0d |  | Infographiste [80%]; Responsable de production [20%] | 80h | 4,047.36 |
| 109 | 1.10.4.4 | Réaliser le montage informatique | 10d | 2014-12-02 | 2014-12-15 | 106, 107, 108 | 64d | 0d |  | Développeur informaticien [80%]; Responsable de production [40%] | 96h | 5,946.24 |
| 110 | 1.10.4.5 | Développer le dispositif d'utilisation du programme | 20d | 2014-11-18 | 2014-12-15 | 104 | 89d |  |  | Développeur informaticien [60%]; Responsable de production [10%] | 112h | 7,187.52 |
| 111 | 1.10.5 | **Evaluer le programme** | 25d | 2014-12-16 | 2015-01-19 |  | 64d |  |  |  | 184h | 11,920.48 |
| 112 | 1.10.5.1 | Réaliser le test alpha | 5d | 2014-12-16 | 2014-12-22 | 109 | 64d | 0d |  | Responsable de production [40%]; Développeur informaticien [40%]; Infographiste [40%] | 48h | 2,714.88 |
| 113 | 1.10.5.2 | Apporter les corrections suite au test alpha | 5d | 2014-12-23 | 2014-12-29 | 112 | 64d | 0d |  | Développeur informaticien [40%]; Infographiste [40%] | 32h | 1,848.96 |
| 114 | 1.10.5.3 | Réaliser le test Bèta | 10d | 2014-12-30 | 2015-01-12 | 113 | 64d | 0d |  | Chef de projet [30%]; Responsable de production [30%]; Développeur informaticien [30%]; Frais de déplacement | 72h | 5,507.68 |
| 115 | 1.10.5.4 | Apporter les corrections suite au test Béta | 5d | 2015-01-13 | 2015-01-19 | 114 | 64d |  |  | Développeur informaticien [40%]; Infographiste [40%] | 32h | 1,848.96 |
| 116 | 1.10.6 | Manager le projet (5% du travail total de la main d'œuvre) | 80d | 2014-09-30 | 2015-01-19 |  | 64d |  | start no earlier than 2014-09-30 | Chef de projet [6.2%] | 40h | 2,714 |
| 117 | 1.11 | **CONTRAT sans Vidéo N°8** | 80d | 2014-10-28 | 2015-02-16 |  | 44d |  |  |  | 808h | 58,858.32 |
| 118 | 1.11.1 | Repérer, extraire (besoins, pbs, désirs,…) à partir des entretiens qualitatifs | 10d | 2014-10-28 | 2014-11-10 |  | 44d | 0d | start no earlier than 2014-10-28 | Chef de projet [50%]; Frais de déplacement | 40h | 3,714 |
| 119 | 1.11.2 | Modéliser les contenus | 15d | 2014-11-11 | 2014-12-01 | 118 | 44d | 0d |  | Auteur [66.7%]; Responsable de production [13.3%] | 96h | 8,865.92 |
| 120 | 1.11.3 | Scénariser le programme de formation | 10d | 2014-12-02 | 2014-12-15 | 119 | 44d | 0d |  | Scénariste [70%]; Chef de projet [10%] | 64h | 6,142.8 |
| 121 | 1.11.4 | **Produire le programme** | 20d | 2014-12-16 | 2015-01-12 |  | 44d |  |  |  | 384h | 25,501.12 |
| 122 | 1.11.4.1 | Rédiger les textes | 10d | 2014-12-16 | 2014-12-29 | 120 | 44d | 0d |  | Auteur [80%] | 64h | 6,400 |
| 123 | 1.11.4.2 | Réaliser les photographies | 5d | 2014-12-16 | 2014-12-22 | 120 | 49d | 5d |  | Photographe [80%] | 32h | 1,920 |
| 124 | 1.11.4.3 | Dessiner les illustrations | 10d | 2014-12-16 | 2014-12-29 | 120 | 44d | 0d |  | Infographiste [80%]; Responsable de production [20%] | 80h | 4,047.36 |
| 125 | 1.11.4.4 | Réaliser le montage informatique | 10d | 2014-12-30 | 2015-01-12 | 122, 123, 124 | 44d | 0d |  | Développeur informaticien [80%]; Responsable de production [40%] | 96h | 5,946.24 |
| 126 | 1.11.4.5 | Développer le dispositif d'utilisation du programme | 20d | 2014-12-16 | 2015-01-12 | 120 | 69d |  |  | Développeur informaticien [60%]; Responsable de production [10%] | 112h | 7,187.52 |
| 127 | 1.11.5 | **Evaluer le programme** | 25d | 2015-01-13 | 2015-02-16 |  | 44d |  |  |  | 184h | 11,920.48 |
| 128 | 1.11.5.1 | Réaliser le test alpha | 5d | 2015-01-13 | 2015-01-19 | 125 | 44d | 0d |  | Responsable de production [40%]; Développeur informaticien [40%]; Infographiste [40%] | 48h | 2,714.88 |
| 129 | 1.11.5.2 | Apporter les corrections suite au test alpha | 5d | 2015-01-20 | 2015-01-26 | 128 | 44d | 0d |  | Développeur informaticien [40%]; Infographiste [40%] | 32h | 1,848.96 |
| 130 | 1.11.5.3 | Réaliser le test Bèta | 10d | 2015-01-27 | 2015-02-09 | 129 | 44d | 0d |  | Chef de projet [30%]; Responsable de production [30%]; Développeur informaticien [30%]; Frais de déplacement | 72h | 5,507.68 |
| 131 | 1.11.5.4 | Apporter les corrections suite au test Béta | 5d | 2015-02-10 | 2015-02-16 | 130 | 44d |  |  | Développeur informaticien [40%]; Infographiste [40%] | 32h | 1,848.96 |
| 132 | 1.11.6 | Manager le projet (5% du travail total de la main d'œuvre) | 80d | 2014-10-28 | 2015-02-16 |  | 44d |  | start no earlier than 2014-10-28 | Chef de projet [6.2%] | 40h | 2,714 |

| ID | WBS | Task | Duration | Start | Finish | Predecessors | Total slack | Free slack | Constraint | Resources | Work | Cost |
| --- | --- | --- | --- | --- | --- | --- | --- | --- | --- | --- | --- | --- |
| 133 | 1.12 | **CONTRAT sans Vidéo N°9** | 80d | 2014-12-01 | 2015-03-20 |  | 20d |  |  |  | 808h | 58,858.32 |
| 134 | 1.12.1 | Repérer, extraire (besoins, pbs, désirs,…) à partir des entretiens qualitatifs | 10d | 2014-12-01 | 2014-12-12 |  | 20d | 0d | start no earlier than 2014-12-01 | Chef de projet [50%]; Frais de déplacement | 40h | 3,714 |
| 135 | 1.12.2 | Modéliser les contenus | 15d | 2014-12-15 | 2015-01-02 | 134 | 20d | 0d |  | Auteur [66.7%]; Responsable de production [13.3%] | 96h | 8,865.92 |
| 136 | 1.12.3 | Scénariser le programme de formation | 10d | 2015-01-05 | 2015-01-16 | 135 | 20d | 0d |  | Scénariste [70%]; Chef de projet [10%] | 64h | 6,142.8 |
| 137 | 1.12.4 | **Produire le programme** | 20d | 2015-01-19 | 2015-02-13 |  | 20d |  |  |  | 384h | 25,501.12 |
| 138 | 1.12.4.1 | Rédiger les textes | 10d | 2015-01-19 | 2015-01-30 | 136 | 20d | 0d |  | Auteur [80%] | 64h | 6,400 |
| 139 | 1.12.4.2 | Réaliser les photographies | 5d | 2015-01-19 | 2015-01-23 | 136 | 25d | 5d |  | Photographe [80%] | 32h | 1,920 |
| 140 | 1.12.4.3 | Dessiner les illustrations | 10d | 2015-01-19 | 2015-01-30 | 136 | 20d | 0d |  | Infographiste [80%]; Responsable de production [20%] | 80h | 4,047.36 |
| 141 | 1.12.4.4 | Réaliser le montage informatique | 10d | 2015-02-02 | 2015-02-13 | 138, 139, 140 | 20d | 0d |  | Développeur informaticien [80%]; Responsable de production [40%] | 96h | 5,946.24 |
| 142 | 1.12.4.5 | Développer le dispositif d'utilisation du programme | 20d | 2015-01-19 | 2015-02-13 | 136 | 45d |  |  | Développeur informaticien [60%]; Responsable de production [10%] | 112h | 7,187.52 |
| 143 | 1.12.5 | **Evaluer le programme** | 25d | 2015-02-16 | 2015-03-20 |  | 20d |  |  |  | 184h | 11,920.48 |
| 144 | 1.12.5.1 | Réaliser le test alpha | 5d | 2015-02-16 | 2015-02-20 | 141 | 20d | 0d |  | Responsable de production [40%]; Développeur informaticien [40%]; Infographiste [40%] | 48h | 2,714.88 |
| 145 | 1.12.5.2 | Apporter les corrections suite au test alpha | 5d | 2015-02-23 | 2015-02-27 | 144 | 20d | 0d |  | Développeur informaticien [40%]; Infographiste [40%] | 32h | 1,848.96 |
| 146 | 1.12.5.3 | Réaliser le test Bèta | 10d | 2015-03-02 | 2015-03-13 | 145 | 20d | 0d |  | Chef de projet [30%]; Responsable de production [30%]; Développeur informaticien [30%]; Frais de déplacement | 72h | 5,507.68 |
| 147 | 1.12.5.4 | Apporter les corrections suite au test Béta | 5d | 2015-03-16 | 2015-03-20 | 146 | 20d |  |  | Développeur informaticien [40%]; Infographiste [40%] | 32h | 1,848.96 |
| 148 | 1.12.6 | Manager le projet (5% du travail total de la main d'œuvre) | 80d | 2014-12-01 | 2015-03-20 |  | 20d |  | start no earlier than 2014-12-01 | Chef de projet [6.2%] | 40h | 2,714 |
| 149 | 1.13 | **CONTRAT sans Vidéo N°10** | 80d | 2014-12-29 | 2015-04-17 |  | 0d |  |  |  | 808h | 58,858.32 |
| 150 | 1.13.1 | Repérer, extraire (besoins, pbs, désirs,…) à partir des entretiens qualitatifs | 10d | 2014-12-29 | 2015-01-09 |  | 0d |  | start no earlier than 2014-12-29 | Chef de projet [50%]; Frais de déplacement | 40h | 3,714 |
| 151 | 1.13.2 | Modéliser les contenus | 15d | 2015-01-12 | 2015-01-30 | 150 | 0d |  |  | Auteur [66.7%]; Responsable de production [13.3%] | 96h | 8,865.92 |
| 152 | 1.13.3 | Scénariser le programme de formation | 10d | 2015-02-02 | 2015-02-13 | 151 | 0d |  |  | Scénariste [70%]; Chef de projet [10%] | 64h | 6,142.8 |
| 153 | 1.13.4 | **Produire le programme** | 20d | 2015-02-16 | 2015-03-13 |  | 0d |  |  |  | 384h | 25,501.12 |
| 154 | 1.13.4.1 | Rédiger les textes | 10d | 2015-02-16 | 2015-02-27 | 152 | 0d |  |  | Auteur [80%] | 64h | 6,400 |
| 155 | 1.13.4.2 | Réaliser les photographies | 5d | 2015-02-16 | 2015-02-20 | 152 | 5d |  |  | Photographe [80%] | 32h | 1,920 |
| 156 | 1.13.4.3 | Dessiner les illustrations | 10d | 2015-02-16 | 2015-02-27 | 152 | 0d |  |  | Infographiste [80%]; Responsable de production [20%] | 80h | 4,047.36 |
| 157 | 1.13.4.4 | Réaliser le montage informatique | 10d | 2015-03-02 | 2015-03-13 | 154, 155, 156 | 0d |  |  | Développeur informaticien [80%]; Responsable de production [40%] | 96h | 5,946.24 |
| 158 | 1.13.4.5 | Développer le dispositif d'utilisation du programme | 20d | 2015-02-16 | 2015-03-13 | 152 | 25d |  |  | Développeur informaticien [60%]; Responsable de production [10%] | 112h | 7,187.52 |

| ID | WBS | Task | Duration | Start | Finish | Predecessors | Total slack | Constraint | Resources | Work | Cost |
| --- | --- | --- | --- | --- | --- | --- | --- | --- | --- | --- | --- |
| 159 | 1.13.5 | **Evaluer le programme** | 25d | 2015-03-16 | 2015-04-17 |  | 0d |  |  | 184h | 11,920.48 |
| 160 | 1.13.5.1 | Réaliser le test alpha | 5d | 2015-03-16 | 2015-03-20 | 157 | 0d |  | Responsable de production [40%]; Développeur informaticien [40%]; Infographiste [40%] | 48h | 2,714.88 |
| 161 | 1.13.5.2 | Apporter les corrections suite au test alpha | 5d | 2015-03-23 | 2015-03-27 | 160 | 0d |  | Développeur informaticien [40%]; Infographiste [40%] | 32h | 1,848.96 |
| 162 | 1.13.5.3 | Réaliser le test Bèta | 10d | 2015-03-30 | 2015-04-10 | 161 | 0d |  | Chef de projet [30%]; Responsable de production [30%]; Développeur informaticien [30%]; Frais de déplacement | 72h | 5,507.68 |
| 163 | 1.13.5.4 | Apporter les corrections suite au test Béta | 5d | 2015-04-13 | 2015-04-17 | 162 | 0d |  | Développeur informaticien [40%]; Infographiste [40%] | 32h | 1,848.96 |
| 164 | 1.13.6 | Manager le projet (5% du travail total de la main d'œuvre) | 80d | 2014-12-29 | 2015-04-17 |  | 0d | start no earlier than 2014-12-29 | Chef de projet [6.2%] | 40h | 2,714 |
